# MTP-1

Schedule from MS Project, 2014-05-26 to 2015-02-26.
Cuvenpetrol, S.A.

## Calendars

- Estándar: Mon-Fri 09:00-13:00, 15:00-19:00; Sat-Sun off.

## Resources

| Resource |
| --- |
| Bulldozer SD-22 |
| Bulldozer SD-16 |
| Cargador SL-50W |
| Compactador SR-20M |
| Motoniveladora SG 18-3 |
| Retroexcavadora JYL 210E |
| Camión cisterna QDZ5190GJY |
| Camión volteo ZZ3257N3241 |
| Comisión de estudio |

## Schedule

| ID | WBS | Task | Duration | Start | Finish | Predecessors | Total slack | Resources | Work |
| --- | --- | --- | --- | --- | --- | --- | --- | --- | --- |
| 1 | 1 | **Terraza no. 4** | 199d | 2014-05-26 | 2015-02-26 |  | 0d |  | 30720h |
| 2 | 1.1 | **Trabajos preliminares** | 8d | 2014-05-26 | 2014-06-04 |  | 0d |  | 64h |
| 3 | 1.1.1 | Replanteo preliminar | 1d | 2014-05-26 | 2014-05-26 |  | 0d | Comisión de estudio | 8h |
| 4 | 1.1.2 | Desbroce | 7d | 2014-05-27 | 2014-06-04 | 3 | 0d | Bulldozer SD-22 | 56h |
| 5 | 1.2 | **Berma no. 1** | 8d | 2014-05-28 | 2014-06-06 |  | 0d |  | 400h |
| 6 | 1.2.1 | Extracción de capa vegetal | 2d | 2014-05-28 | 2014-05-29 | 4SS+1d | 0d | Bulldozer SD-22 [300%] | 48h |
| 7 | 1.2.2 | Carga y transp. de vegetal | 2d | 2014-05-28 | 2014-05-30 | 6SS+0.5d | 0d | Cargador SL-50W; Camión volteo ZZ3257N3241 [200%] | 24h |
| 8 | 1.2.3 | Replanteo definitivo | 1d | 2014-05-30 | 2014-06-02 | 7 | 0d | Comisión de estudio | 8h |
| 9 | 1.2.4 | Excavación, perfilado y nivelación | 3d | 2014-06-02 | 2014-06-05 | 8 | 0d | Bulldozer SD-22 [200%]; Motoniveladora SG 18-3 | 48h |
| 10 | 1.2.5 | Carga y transp. de mat. Excavado | 3d | 2014-06-03 | 2014-06-05 | 9SS+0.5d | 0d | Cargador SL-50W; Camión volteo ZZ3257N3241 | 48h |
| 11 | 1.2.6 | Relleno, nivelación y compactación | 3.5d | 2014-06-03 | 2014-06-06 | 10SS+0.5d | 0d | Bulldozer SD-16 [400%]; Motoniveladora SG 18-3 [300%]; Compactador SR-20M [200%]; Camión cisterna QDZ5190GJY [700%] | 224h |
| 12 | 1.3 | **Berma no. 2** | 15d | 2014-06-09 | 2014-06-27 |  | 0d |  | 2312h |
| 13 | 1.3.1 | Extracción de capa vegetal | 3d | 2014-06-09 | 2014-06-11 | 11 | 0d | Bulldozer SD-22 [300%] | 72h |
| 14 | 1.3.2 | Carga y transp. de vegetal | 3d | 2014-06-09 | 2014-06-12 | 13SS+0.5d | 0d | Cargador SL-50W; Camión volteo ZZ3257N3241 [200%] | 72h |
| 15 | 1.3.3 | Replanteo definitivo | 1d | 2014-06-12 | 2014-06-13 | 14 | 0d | Comisión de estudio | 8h |
| 16 | 1.3.4 | Excavación, perfilado y nivelación | 3d | 2014-06-16 | 2014-06-18 | 15FS+0.5d | 0d | Bulldozer SD-22 [200%]; Motoniveladora SG 18-3 | 72h |
| 17 | 1.3.5 | Carga y transp. de mat. Excavado | 9d | 2014-06-16 | 2014-06-27 | 16SS+0.5d | 0d | Cargador SL-50W [200%]; Camión volteo ZZ3257N3241 [800%] | 720h |
| 18 | 1.3.6 | Relleno, nivelación y compactación | 9d | 2014-06-17 | 2014-06-27 | 17SS+0.5d | 0d | Bulldozer SD-16 [500%]; Motoniveladora SG 18-3 [400%]; Compactador SR-20M [300%]; Camión cisterna QDZ5190GJY [700%] | 1368h |
| 19 | 1.4 | **Berma no. 3** | 17.5d | 2014-06-30 | 2014-07-23 |  | 0d |  | 3160h |
| 20 | 1.4.1 | Extracción de capa vegetal | 4d | 2014-06-30 | 2014-07-03 | 18 | 0d | Bulldozer SD-22 [300%] | 96h |
| 21 | 1.4.2 | Carga y transp. de vegetal | 4d | 2014-06-30 | 2014-07-04 | 20SS+0.5d | 0d | Cargador SL-50W; Camión volteo ZZ3257N3241 [200%] | 96h |
| 22 | 1.4.3 | Replanteo definitivo | 1d | 2014-07-04 | 2014-07-07 | 21 | 0d | Comisión de estudio | 8h |
| 23 | 1.4.4 | Excavación, perfilado y nivelación | 10d | 2014-07-07 | 2014-07-21 | 22 | 0d | Bulldozer SD-22 [200%]; Motoniveladora SG 18-3 [200%] | 320h |
| 24 | 1.4.5 | Carga y transp. de mat. Excavado | 11d | 2014-07-08 | 2014-07-22 | 23SS+0.5d | 0d | Cargador SL-50W [200%]; Camión volteo ZZ3257N3241 [800%] | 880h |
| 25 | 1.4.6 | Relleno, nivelación y compactación | 11d | 2014-07-08 | 2014-07-23 | 24SS+0.5d | 0d | Bulldozer SD-16 [500%]; Motoniveladora SG 18-3 [400%]; Compactador SR-20M [400%]; Camión cisterna QDZ5190GJY [700%] | 1760h |

| ID | WBS | Task | Duration | Start | Finish | Predecessors | Total slack | Resources | Work |
| --- | --- | --- | --- | --- | --- | --- | --- | --- | --- |
| 26 | 1.5 | **Berma no. 4** | 18d | 2014-07-23 | 2014-08-18 |  | 0d |  | 2928h |
| 27 | 1.5.1 | Extracción de capa vegetal | 5d | 2014-07-23 | 2014-07-30 | 25 | 0d | Bulldozer SD-22 [300%] | 120h |
| 28 | 1.5.2 | Carga y transp. de vegetal | 5d | 2014-07-24 | 2014-07-30 | 27SS+0.5d | 0d | Cargador SL-50W; Camión volteo ZZ3257N3241 [200%] | 120h |
| 29 | 1.5.3 | Replanteo definitivo | 1d | 2014-07-31 | 2014-07-31 | 28 | 0d | Comisión de estudio | 8h |
| 30 | 1.5.4 | Excavación, perfilado y nivelación | 3d | 2014-08-01 | 2014-08-05 | 29 | 0d | Bulldozer SD-22 [200%]; Motoniveladora SG 18-3 [200%] | 96h |
| 31 | 1.5.5 | Carga y transp. de mat. Excavado | 11d | 2014-08-01 | 2014-08-18 | 30SS+0.5d | 0d | Cargador SL-50W [200%]; Camión volteo ZZ3257N3241 [1100%] | 1144h |
| 32 | 1.5.6 | Relleno, nivelación y compactación | 9d | 2014-08-04 | 2014-08-14 | 31SS+0.5d | 0d | Bulldozer SD-16 [500%]; Motoniveladora SG 18-3 [400%]; Compactador SR-20M [400%]; Camión cisterna QDZ5190GJY [700%] | 1440h |
| 33 | 1.6 | **Berma no. 5** | 18d | 2014-08-15 | 2014-09-09 |  | 0d |  | 1824h |
| 34 | 1.6.1 | Extracción de capa vegetal | 5d | 2014-08-15 | 2014-08-21 | 32 | 0d | Bulldozer SD-22 [400%] | 160h |
| 35 | 1.6.2 | Carga y transp. de vegetal | 5d | 2014-08-15 | 2014-08-22 | 34SS+0.5d | 0d | Cargador SL-50W; Camión volteo ZZ3257N3241 [300%] | 160h |
| 36 | 1.6.3 | Replanteo definitivo | 1d | 2014-08-22 | 2014-08-25 | 35 | 0d | Comisión de estudio | 8h |
| 37 | 1.6.4 | Excavación, perfilado y nivelación | 11d | 2014-08-25 | 2014-09-09 | 36 | 0d | Bulldozer SD-22 [200%]; Motoniveladora SG 18-3 [200%] | 352h |
| 38 | 1.6.5 | Carga y transp. de mat. Excavado | 11d | 2014-08-26 | 2014-09-09 | 37SS+0.5d | 0d | Cargador SL-50W [200%]; Camión volteo ZZ3257N3241 [1100%] | 1144h |
| 39 | 1.7 | **Berma no. 6** | 17d | 2014-09-10 | 2014-10-02 |  | 0d |  | 1792h |
| 40 | 1.7.1 | Extracción de capa vegetal | 4d | 2014-09-10 | 2014-09-15 | 38 | 0d | Bulldozer SD-22 | 32h |
| 41 | 1.7.2 | Carga y transp. de vegetal | 4d | 2014-09-10 | 2014-09-16 | 40SS+0.5d | 0d | Cargador SL-50W [400%]; Camión volteo ZZ3257N3241 [400%] | 256h |
| 42 | 1.7.3 | Replanteo definitivo | 1d | 2014-09-16 | 2014-09-17 | 41 | 0d | Comisión de estudio | 8h |
| 43 | 1.7.4 | Excavación, perfilado y nivelación | 11d | 2014-09-17 | 2014-10-02 | 42 | 0d | Bulldozer SD-22 [200%]; Motoniveladora SG 18-3 [300%] | 440h |
| 44 | 1.7.5 | Carga y transp. de mat. Excavado | 11d | 2014-09-18 | 2014-10-02 | 43SS+0.5d | 0d | Cargador SL-50W [200%]; Camión volteo ZZ3257N3241 [1000%] | 1056h |
| 45 | 1.8 | **Berma no. 7** | 22d | 2014-10-03 | 2014-11-03 |  | 0d |  | 3016h |
| 46 | 1.8.1 | Extracción de capa vegetal | 6d | 2014-10-03 | 2014-10-10 | 44 | 0d | Bulldozer SD-22 [400%] | 192h |
| 47 | 1.8.2 | Carga y transp. de vegetal | 6d | 2014-10-03 | 2014-10-13 | 46SS+0.5d | 0d | Cargador SL-50W; Camión volteo ZZ3257N3241 [400%] | 240h |
| 48 | 1.8.3 | Replanteo definitivo | 1d | 2014-10-13 | 2014-10-14 | 47 | 0d | Comisión de estudio | 8h |
| 49 | 1.8.4 | Excavación, perfilado y nivelación | 14d | 2014-10-14 | 2014-11-03 | 48 | 0d | Bulldozer SD-22 [500%]; Motoniveladora SG 18-3 [500%] | 1120h |
| 50 | 1.8.5 | Carga y transp. de mat. Excavado | 14d | 2014-10-15 | 2014-11-03 | 49SS+0.5d | 0d | Cargador SL-50W [200%]; Camión volteo ZZ3257N3241 [1100%] | 1456h |

| ID | WBS | Task | Duration | Start | Finish | Predecessors | Total slack | Resources | Work |
| --- | --- | --- | --- | --- | --- | --- | --- | --- | --- |
| 51 | 1.9 | **Berma no. 8** | 22d | 2014-11-04 | 2014-12-03 |  | 0d |  | 3016h |
| 52 | 1.9.1 | Extracción de capa vegetal | 6d | 2014-11-04 | 2014-11-11 | 50 | 0d | Bulldozer SD-22 [400%] | 192h |
| 53 | 1.9.2 | Carga y transp. de vegetal | 6d | 2014-11-04 | 2014-11-12 | 52SS+0.5d | 0d | Cargador SL-50W; Camión volteo ZZ3257N3241 [400%] | 240h |
| 54 | 1.9.3 | Replanteo definitivo | 1d | 2014-11-12 | 2014-11-13 | 53 | 0d | Comisión de estudio | 8h |
| 55 | 1.9.4 | Excavación, perfilado y nivelación | 14d | 2014-11-13 | 2014-12-03 | 54 | 0d | Bulldozer SD-22 [500%]; Motoniveladora SG 18-3 [500%] | 1120h |
| 56 | 1.9.5 | Carga y transp. de mat. Excavado | 14d | 2014-11-14 | 2014-12-03 | 55SS+0.5d | 0d | Cargador SL-50W [200%]; Camión volteo ZZ3257N3241 [1100%] | 1456h |
| 57 | 1.10 | **Berma no. 9** | 20d | 2014-12-04 | 2014-12-31 |  | 0d |  | 2872h |
| 58 | 1.10.1 | Extracción de capa vegetal | 4d | 2014-12-04 | 2014-12-09 | 56 | 0d | Bulldozer SD-22 [400%] | 128h |
| 59 | 1.10.2 | Carga y transp. de vegetal | 4d | 2014-12-04 | 2014-12-10 | 58SS+0.5d | 0d | Cargador SL-50W; Camión volteo ZZ3257N3241 [400%] | 160h |
| 60 | 1.10.3 | Replanteo definitivo | 1d | 2014-12-10 | 2014-12-11 | 59 | 0d | Comisión de estudio | 8h |
| 61 | 1.10.4 | Excavación, perfilado y nivelación | 14d | 2014-12-11 | 2014-12-31 | 60 | 0d | Bulldozer SD-22 [500%]; Motoniveladora SG 18-3 [500%] | 1120h |
| 62 | 1.10.5 | Carga y transp. de mat. Excavado | 14d | 2014-12-12 | 2014-12-31 | 61SS+0.5d | 0d | Cargador SL-50W [200%]; Camión volteo ZZ3257N3241 [1100%] | 1456h |
| 63 | 1.11 | **Terraza 4** | 41d | 2015-01-01 | 2015-02-26 |  | 0d |  | 9336h |
| 64 | 1.11.1 | Extracción de capa vegetal | 10d | 2015-01-01 | 2015-01-14 | 62 | 0d | Bulldozer SD-22 [400%] | 320h |
| 65 | 1.11.2 | Carga y transp. de vegetal | 11d | 2015-01-01 | 2015-01-16 | 64SS+0.5d | 0d | Cargador SL-50W [200%]; Camión volteo ZZ3257N3241 [700%] | 792h |
| 66 | 1.11.3 | Replanteo definitivo | 2d | 2015-01-16 | 2015-01-20 | 65 | 0d | Comisión de estudio | 16h |
| 67 | 1.11.4 | Excavación, perfilado y nivelación | 27d | 2015-01-20 | 2015-02-26 | 66 | 0d | Bulldozer SD-22 [800%]; Motoniveladora SG 18-3 [900%] | 3672h |
| 68 | 1.11.5 | Carga y transp. de mat. Excavado | 27d | 2015-01-21 | 2015-02-26 | 67SS+0.5d | 0d | Cargador SL-50W [300%]; Camión volteo ZZ3257N3241 [1800%] | 4536h |
